# Plano de Marketing

Schedule from MS Project, 2010-09-20 to 2010-12-29.
.

## Calendars

- Padrão: Mon-Fri 09:00-12:00, 13:00-18:00; Sat-Sun off.

## Resources

| Resource | Group | Rate | Cost per use |
| --- | --- | --- | --- |
| Gerente de Marketing | Marketing | 28.12 |  |
| Analista de Marketing | Marketing | 12.5 |  |
| Material Publicitário | Divulgação |  | 10000 |
| Divulga Bem Ltda (Agência) | Contratado |  |  |

## Schedule

| ID | WBS | Task | Type | Duration | Start | Finish | Predecessors | Total slack | Free slack |
| --- | --- | --- | --- | --- | --- | --- | --- | --- | --- |
| 1 | 1 | **Plano de Marketing** |  | 73d | 2010-09-20 | 2010-12-29 |  | 0d |  |
| 2 | 1.1 | **Análise do Mercado** |  | 7d | 2010-09-20 | 2010-09-28 |  | 0d |  |
| 3 | 1.1.1 | Definir público-alvo |  | 3d | 2010-09-20 | 2010-09-22 |  | 0d |  |
| 4 | 1.1.2 | Analisar divisão do mercado |  | 2d | 2010-09-23 | 2010-09-24 | 3 | 0d |  |
| 5 | 1.1.3 | Analisar forças e fraquezas do produto |  | 2d | 2010-09-27 | 2010-09-28 | 4 | 0d |  |
| 6 | 1.2 | **Análise da Concorrência** |  | 5d | 2010-09-23 | 2010-09-29 |  | 0d |  |
| 7 | 1.2.1 | Analisar pontos fortes e fracos |  | 3d | 2010-09-27 | 2010-09-29 | 5SS | 0d |  |
| 8 | 1.2.2 | Posicionar produto para cada concorrente |  | 2d | 2010-09-23 | 2010-09-24 | 4SS | 2d | 0d |
| 9 | 1.2.3 | Avaliar oportunidades e ameaças |  | 2d | 2010-09-24 | 2010-09-27 | 8FS-5% | 2d |  |
| 10 | 1.3 | Análise do mercado finalizada | milestone | 0d | 2010-09-29 | 2010-09-29 | 9, 7 | 0d |  |
| 11 | 1.4 | **Definição de Metas** |  | 3d | 2010-09-30 | 2010-10-04 |  | 0d |  |
| 12 | 1.4.1 | Definir volume de vendas no primeiro ano |  | 3d | 2010-09-30 | 2010-10-04 | 10 | 0d |  |
| 13 | 1.4.2 | Definir participação no mercado no primeiro ano |  | 2d | 2010-10-01 | 2010-10-04 | 12FF | 0d |  |
| 14 | 1.5 | Definição de metas concluído | milestone | 0d | 2010-10-04 | 2010-10-04 | 13 | 0d |  |
| 15 | 1.6 | **Planejamento dos Canais de distribuição** |  | 7d | 2010-10-05 | 2010-10-13 |  | 0d |  |
| 16 | 1.6.1 | Definir canais de distribuição |  | 2d | 2010-10-05 | 2010-10-06 | 14 | 0d |  |
| 17 | 1.6.2 | Definir estratégias e políticas de distribuição |  | 3d | 2010-10-07 | 2010-10-11 | 16 | 2d |  |
| 18 | 1.6.3 | Selecionar os canais de distribuição |  | 4d | 2010-10-06 | 2010-10-11 | 16FS-5% | 0d |  |
| 19 | 1.6.4 | Definir os preços para revenda |  | 2d | 2010-10-12 | 2010-10-13 | 18 | 0d |  |
| 20 | 1.7 | Planejamento dos canais de distribuição finalizado | milestone | 0d | 2010-10-13 | 2010-10-13 | 19, 17 | 0d |  |
| 21 | 1.8 | **Estratégias de Comunicação** |  | 55d | 2010-10-14 | 2010-12-29 |  | 0d |  |
| 22 | 1.8.1 | Definir mensagens de acordo com o público-alvo |  | 1w | 2010-10-14 | 2010-10-20 | 20 | 0d |  |
| 23 | 1.8.2 | Definição de calendários editoriais |  | 3d | 2010-10-21 | 2010-10-25 | 22 | 0d |  |
| 24 | 1.8.3 | **Palestras e Workshops estratégicos** |  | 19d | 2010-10-26 | 2010-11-19 |  | 0d |  |
| 25 | 1.8.3.1 | Definir cronograma de palestras/workshops |  | 3d | 2010-10-26 | 2010-10-28 | 23 | 0d |  |
| 26 | 1.8.3.2 | Ministrar evento de lançamento do produto |  | 1d | 2010-10-29 | 2010-10-29 | 25 | 0d |  |
| 27 | 1.8.3.3 | Ministrar palestras e workshops estratégicos |  | 15d | 2010-11-01 | 2010-11-19 | 26 | 0d |  |

| ID | WBS | Task | Type | Duration | Start | Finish | Predecessors | Total slack |
| --- | --- | --- | --- | --- | --- | --- | --- | --- |
| 28 | 1.8.4 | **Planejamento da campanha publicitária** |  | 28d | 2010-11-22 | 2010-12-29 |  | 0d |
| 29 | 1.8.4.1 | Contatar veículos de propaganda |  | 2d | 2010-11-22 | 2010-11-23 | 27 | 0d |
| 30 | 1.8.4.2 | Definir campanha publicitária |  | 1w | 2010-11-22 | 2010-11-26 | 29SS | 0d |
| 31 | 1.8.4.3 | Análise do programa publicitário |  | 4d | 2010-11-25 | 2010-11-30 | 30FS-2d | 0d |
| 32 | 1.8.4.4 | Obter aprovação da campanha publicitária |  | 2d | 2010-12-01 | 2010-12-02 | 31 | 0d |
| 33 | 1.8.4.5 | Campanha publicitária aprovada | milestone | 0d | 2010-12-02 | 2010-12-02 | 32 | 0d |
| 34 | 1.8.4.6 | Selecionar canais de veiculação |  | 1w | 2010-12-03 | 2010-12-09 | 33 | 0d |
| 35 | 1.8.4.7 | Comprar material de publicidade |  | 4d | 2010-12-10 | 2010-12-15 | 34 | 0d |
| 36 | 1.8.4.8 | Conferir material de publicidade |  | 2d | 2010-12-14 | 2010-12-15 | 35FS-5% | 0d |
| 37 | 1.8.4.9 | Veiculação Comercial na Mídia |  | 2w | 2010-12-16 | 2010-12-29 | 36 | 0d |
| 38 | 1.9 | Estratégias de Comunicação finalizadas | milestone | 0d | 2010-12-29 | 2010-12-29 | 37 | 0d |
| 39 | 2 | Plano de Marketing Finalizado | milestone | 0d | 2010-12-29 | 2010-12-29 | 38 | 0d |
