# Preparação de Relatório Anual

Schedule from MS Project, 2007-01-01 to 2017-08-28.
Utilizando um modo de exibição de Finanças e Contabilidade, este modelo aborda as atividades gerais que definem um esforço típico para a preparação do Relatório Financeiro Anual. O modelo inclui desde as atividades focadas na obtenção das informações necessárias de diversos departamentos e no trabalho com outros departamentos (por ex., Jurídico e Relações Públicas), de modo a garantir que todas as informações necessárias sejam apresentadas de modo preciso, até o processo de impressão e distribuição.

## Calendars

- Padrão: Mon-Fri 09:00-12:00, 13:00-18:00; Sat-Sun off.

## Resources

| Resource |
| --- |
| Comitê de Auditoria |
| Departamento Jurídico |
| Auditores Externos |
| Comitê Executivo |
| Diretor Financeiro/Controlador |
| Grupo de Marketing |
| Comitê de Planejamento Estratégico |
| Depto. de RP/RI |
| Presidente |

## Schedule

| ID | WBS | Task | Type | Duration | Start | Finish | Predecessors | Total slack | Free slack | Resources | Work |
| --- | --- | --- | --- | --- | --- | --- | --- | --- | --- | --- | --- |
| 1 | 1 | **Executar Planejamento Inicial** |  | 6d? | 2007-01-01 | 2007-01-08 |  | 0d |  |  | 48h |
| 2 | 1.1 | Revisar arquivo/lições de projeto aprendidos no processo de Relatório Anual do ano passado |  | 1d? | 2017-06-30 | 2017-07-03 |  | 0d |  | Comitê de Planejamento Estratégico | 8h |
| 3 | 1.2 | Confirmar alterações, se houver, de requisitos de relatórios financeiros |  | 1d? | 2017-07-03 | 2017-07-03 | 2 | 0d |  | Diretor Financeiro/Controlador | 8h |
| 4 | 1.3 | Identificar Tema do Relatório Anual e Requisitos de Seção |  | 1d? | 2017-07-03 | 2017-07-03 | 3 | 0d |  | Comitê de Planejamento Estratégico | 8h |
| 5 | 1.4 | Confirmar outras seções a serem adicionadas ou removidas |  | 1d? | 2017-07-03 | 2017-07-04 | 4 | 0d |  | Comitê de Planejamento Estratégico | 8h |
| 6 | 1.5 | Confirmar Pontos de Verificação do arquivamento SEC e do Relatório Anual |  | 1d? | 2017-07-04 | 2017-07-05 | 5 | 0d |  | Diretor Financeiro/Controlador | 8h |
| 7 | 1.6 | Seleção de Auditores Internos |  | 1d? | 2017-07-07 | 2017-07-10 | 6 | 0d |  | Comitê de Auditoria | 8h |
| 8 | 1.7 | Planejamento Inicial Concluído | milestone | 0d | 2017-07-10 | 2017-07-10 | 7 | 0d |  |  |  |
| 9 | 2 | **Relatório Anual de Design** |  | 6d? | 2007-01-09 | 2007-01-16 |  | 0d |  |  | 48h |
| 10 | 2.1 | Atribuir recursos ao design preliminar |  | 1d? | 2017-07-10 | 2017-07-10 | 8 | 0d |  | Comitê de Planejamento Estratégico | 8h |
| 11 | 2.2 | Desenvolver requisitos de informações e design preliminares |  | 1d? | 2017-07-10 | 2017-07-10 | 10 | 0d |  | Comitê de Planejamento Estratégico | 8h |
| 12 | 2.3 | **Avaliar/Confirmar Mecanismos de Distribuição de Relatório** |  | 3d? | 2007-01-11 | 2007-01-15 |  | 0d |  |  | 24h |
| 13 | 2.3.1 | Avaliar/confirmar fornecedor(es) de comunicações e design do Relatório Anual |  | 1d? | 2017-07-10 | 2017-07-11 | 11 | 0d |  | Depto. de RP/RI | 8h |
| 14 | 2.3.2 | Avaliar/confirmar requisitos de integração e design do site corporativo |  | 1d? | 2017-07-11 | 2017-07-12 | 13 | 0d |  | Depto. de RP/RI | 8h |
| 15 | 2.3.3 | Avaliar/confirmar fornecedor(es) de correspondências e produção do Relatório Anual |  | 1d? | 2017-07-14 | 2017-07-17 | 14 | 0d |  | Depto. de RP/RI | 8h |
| 16 | 2.3.4 | Mecanismos de Distribuição de Relatório Confirmados | milestone | 0d | 2017-07-17 | 2017-07-17 | 15 | 0d |  | Depto. de RP/RI |  |
| 17 | 2.4 | Planejar/confirmar cronograma de produção |  | 1d? | 2017-07-17 | 2017-07-17 | 16 | 0d |  | Depto. de RP/RI | 8h |
| 18 | 2.5 | Design do Relatório Anual Concluído | milestone | 0d | 2017-07-17 | 2017-07-17 | 17 | 0d |  |  |  |
| 19 | 3 | **Definir Cronogramas de Produção do SEC 10-K e da Documentação aos Acionistas** |  | 3d? | 2007-01-17 | 2007-01-19 |  | 0d |  |  | 24h |
| 20 | 3.1 | Planejar/confirmar cronograma de produção do 10-K |  | 1d? | 2017-07-17 | 2017-07-17 | 18 | 0d |  | Diretor Financeiro/Controlador | 8h |
| 21 | 3.2 | Planejar/confirmar cronograma de produção do Relatório aos Acionistas |  | 1d? | 2017-07-17 | 2017-07-18 | 20 | 0d |  | Diretor Financeiro/Controlador | 8h |
| 22 | 3.3 | Identificar as etapas do processo necessárias para atender ao cronograma de produção |  | 1d? | 2017-07-18 | 2017-07-19 | 21 | 0d |  | Diretor Financeiro/Controlador | 8h |
| 23 | 3.4 | Cronogramas de Produção do SEC 10-K e da Documentação aos Acionistas Concluídos | milestone | 0d | 2017-07-19 | 2017-07-19 | 22 | 0d |  |  |  |
| 24 | 4 | **Desenvolver Relatório Anual** |  | 22d? | 2007-01-22 | 2007-02-20 |  | 0d | 5.5d |  | 216h |
| 25 | 4.1 | **Desenvolver componentes de produção do tema** |  | 7d? | 2007-01-22 | 2007-01-30 |  | 0d | 16.5d |  | 56h |
| 26 | 4.1.1 | Agendar e reter sessões de desenvolvimento do tema |  | 1d? | 2017-07-21 | 2017-07-24 | 23 | 0d |  | Depto. de RP/RI | 8h |
| 27 | 4.1.2 | Reunir estatísticas do tema/validar mensagens do tema |  | 1d? | 2017-07-24 | 2017-07-24 | 26 | 0d |  | Depto. de RP/RI | 8h |
| 28 | 4.1.3 | Entrevistar Participantes do Tema |  | 1d? | 2017-07-24 | 2017-07-24 | 27 | 0d |  | Depto. de RP/RI | 8h |
| 29 | 4.1.4 | Desenvolver descrições da seção inicial do tema |  | 1d? | 2017-07-24 | 2017-07-25 | 28 | 0d |  | Depto. de RP/RI | 8h |
| 30 | 4.1.5 | Agendar Sessões de Foto do Tema e Design do Site |  | 1d? | 2017-07-25 | 2017-07-26 | 29 | 0d |  | Depto. de RP/RI | 8h |
| 31 | 4.1.6 | Validar fatos do tema |  | 1d? | 2017-07-28 | 2017-07-31 | 30 | 0d |  | Depto. de RP/RI | 8h |
| 32 | 4.1.7 | Finalizar design e descrições do tema com direção executiva |  | 1d? | 2017-07-31 | 2017-07-31 | 31 | 0d |  | Depto. de RP/RI | 8h |
| 33 | 4.1.8 | Produção do tema concluída | milestone | 0d | 2017-07-31 | 2017-07-31 | 32 | 0d |  |  |  |

Notes:
- 4: Conforme identificação do tema, faça uma lista de participantes a serem envolvidos no conteúdo do tema

| ID | WBS | Task | Type | Duration | Start | Finish | Predecessors | Total slack | Free slack | Resources | Work |
| --- | --- | --- | --- | --- | --- | --- | --- | --- | --- | --- | --- |
| 34 | 4.2 | **Desenvolver Cartas para os Acionistas** |  | 15d? | 2007-01-31 | 2007-02-20 |  | 0d | 5.5d |  | 40h |
| 35 | 4.2.1 | Planejar entrevista com o presidente/CEO |  | 1d? | 2017-07-31 | 2017-07-31 | 33 | 0d |  | Depto. de RP/RI | 8h |
| 36 | 4.2.2 | Conduzir Entrevista |  | 1d? | 2017-07-31 | 2017-08-01 | 35 | 0d |  | Depto. de RP/RI; Presidente | 16h |
| 37 | 4.2.3 | Criar e revisar carta |  | 1d? | 2017-08-01 | 2017-08-02 | 36 | 0d | 11d | Depto. de RP/RI | 8h |
| 38 | 4.2.4 | Revisar carta no contexto com resultados financeiros auditados |  | 1d? | 2017-08-21 | 2017-08-21 | 37, 83 | 0d |  | Depto. de RP/RI | 8h |
| 39 | 4.2.5 | Carta para os Acionistas Concluída | milestone | 0d | 2017-08-21 | 2017-08-21 | 38 | 0d | 5.5d |  |  |
| 40 | 4.3 | **Definir Componentes Baseados nas Relações Públicas e com o Investidor** |  | 10.5d? | 2007-02-06 | 2007-02-20 |  | 0d |  |  | 120h |
| 41 | 4.3.1 | **Definir Etapas de RP e RI** |  | 0.5d? | 2007-02-06 | 2007-02-06 |  | 0d |  |  | 4h |
| 42 | 4.3.1.1 | Definir etapas principais de RP e RI (alinhamento com produtos) |  | 0.5d? | 2017-08-07 | 2017-08-07 | 76 | 0d |  | Depto. de RP/RI | 4h |
| 43 | 4.3.2 | **Desenvolver Sistema de Mensagens de Relações Públicas** |  | 3.5d? | 2007-02-06 | 2007-02-09 |  | 0d | 11d |  | 28h |
| 44 | 4.3.2.1 | Definir sistema de mensagens de RP para inclusão no Relatório Anual |  | 0.5d? | 2017-08-07 | 2017-08-07 | 42 | 0d |  | Depto. de RP/RI | 4h |
| 45 | 4.3.2.2 | Definir sistema de mensagens de RP sobre Resultados Financeiros |  | 2d? | 2017-08-07 | 2017-08-08 | 44 | 0d |  | Depto. de RP/RI | 16h |
| 46 | 4.3.2.3 | Refinar canais de distribuição e linha de tempo |  | 1d? | 2017-08-08 | 2017-08-09 | 45 | 0d | 6d | Depto. de RP/RI | 8h |
| 47 | 4.3.3 | **Desenvolver Sistema de Mensagens de Relações com Investidor** |  | 10d? | 2007-02-06 | 2007-02-20 |  | 0d |  |  | 88h |
| 48 | 4.3.3.1 | Definir sistema de mensagens de RI para Relatório Anual |  | 2d? | 2017-08-07 | 2017-08-08 | 42 | 0d |  | Depto. de RP/RI | 16h |
| 49 | 4.3.3.2 | Definir sistema de mensagens de RI sobre Resultados Financeiros |  | 2d? | 2017-08-07 | 2017-08-09 | 48 | 0d |  | Depto. de RP/RI | 16h |
| 50 | 4.3.3.3 | Confirmar listas e canais de distribuição para geração do Relatório Anual |  | 2d? | 2017-08-11 | 2017-08-15 | 49 | 0d | 3.5d | Depto. de RP/RI | 16h |
| 51 | 4.3.3.4 | Obter resultados financeiros do diretor financeiro |  | 0.5d? | 2017-08-21 | 2017-08-21 | 50, 83 | 0d | 6d | Diretor Financeiro/Controlador; Depto. de RP/RI | 8h |
| 52 | 4.3.3.5 | **Confirmar aquisição da lista de endereçamento e processo de distribuição para acionistas** |  | 4d? | 2007-02-06 | 2007-02-12 |  | 0d |  |  | 32h |
| 53 | 4.3.3.5.1 | Confirmar lista/processo de distribuição institucional |  | 1d? | 2017-08-07 | 2017-08-07 | 42 | 0d |  | Depto. de RP/RI | 8h |
| 54 | 4.3.3.5.2 | Confirmar lista/processo de distribuição de corretagem |  | 1d? | 2017-08-07 | 2017-08-07 | 53 | 0d |  | Depto. de RP/RI | 8h |
| 55 | 4.3.3.5.3 | Confirmar lista/processo de distribuição individual do investidor |  | 1d? | 2017-08-07 | 2017-08-08 | 54 | 0d |  | Depto. de RP/RI | 8h |
| 56 | 4.3.3.5.4 | Confirmar processo de atualização/formatação/postagem do site corporativo |  | 1d? | 2017-08-08 | 2017-08-09 | 55 | 0d |  | Depto. de RP/RI | 8h |
| 57 | 4.3.3.5.5 | Confirmação do Processo de Postagem e Distribuição Concluída | milestone | 0d | 2017-08-11 | 2017-08-11 | 56 | 0d |  |  |  |
| 58 | 4.3.4 | Desenvolvimento e Planejamento de Mensagens das Relações Públicas e com o Investidor Concluídos | milestone | 0d | 2017-08-11 | 2017-08-11 | 57 | 0d |  |  |  |

| ID | WBS | Task | Type | Duration | Start | Finish | Predecessors | Total slack | Free slack | Resources | Work |
| --- | --- | --- | --- | --- | --- | --- | --- | --- | --- | --- | --- |
| 59 | 5 | **Executar Atividades de Fechamento Financeiro** |  | 22.5d? | 2007-01-22 | 2007-02-21 |  | 0d |  |  | 196h |
| 60 | 5.1 | **Definir Agendamento de Componentes de Análise Financeira e de Documento Relacionado do SEC** |  | 5d? | 2007-01-22 | 2007-01-26 |  | 0d |  |  | 48h |
| 61 | 5.1.1 | Desenvolver Cronograma de Fechamento Financeiro |  | 1d? | 2017-07-21 | 2017-07-24 | 23 | 0d |  | Diretor Financeiro/Controlador | 8h |
| 62 | 5.1.2 | Desenvolver e Confirmar Cronograma de Análise de Auditoria Externa |  | 1d? | 2017-07-24 | 2017-07-24 | 61 | 0d |  | Auditores Externos; Diretor Financeiro/Controlador | 16h |
| 63 | 5.1.3 | Identificar/Atribuir recursos para desenvolver e confirmar anotações e Demonstrativos Financeiros |  | 1d? | 2017-07-24 | 2017-07-24 | 62 | 0d |  | Diretor Financeiro/Controlador | 8h |
| 64 | 5.1.4 | Identificar/Atribuir recursos para desenvolver e confirmar a Seção 10-K |  | 1d? | 2017-07-24 | 2017-07-25 | 63 | 0d |  | Diretor Financeiro/Controlador | 8h |
| 65 | 5.1.5 | Identificar/Atribuir recursos para desenvolver e confirmar a Seção de Relatório aos Acionistas |  | 1d? | 2017-07-25 | 2017-07-26 | 64 | 0d |  | Diretor Financeiro/Controlador | 8h |
| 66 | 5.1.6 | Agendamento da Análise Financeira e do Documento Relacionado do SEC concluído | milestone | 0d | 2017-07-26 | 2017-07-26 | 65 | 0d |  |  |  |
| 67 | 5.2 | **Executar Fechamento Financeiro** |  | 3d? | 2007-01-29 | 2007-01-31 |  | 0d |  |  | 24h |
| 68 | 5.2.1 | Encerrar registros do ano fiscal |  | 1d? | 2017-07-28 | 2017-07-31 | 66 | 0d |  | Diretor Financeiro/Controlador | 8h |
| 69 | 5.2.2 | Executar revisão e aprovação dos ajustes financeiros (Acumulações e reservas) |  | 1d? | 2017-07-31 | 2017-07-31 | 68 | 0d |  | Diretor Financeiro/Controlador | 8h |
| 70 | 5.2.3 | Desenvolver resultados financeiros para inclusão no Relatório Anual, 10-K e Relatório aos Acionistas |  | 1d? | 2017-07-31 | 2017-07-31 | 69 | 0d |  | Diretor Financeiro/Controlador | 8h |
| 71 | 5.2.4 | Fechamento e Resultados Financeiros Concluídos | milestone | 0d | 2017-07-31 | 2017-07-31 | 70 | 0d |  |  |  |
| 72 | 5.3 | **Desenvolver Anotações de Demonstrativo Financeiro e Documentos do SEC** |  | 3d? | 2007-02-01 | 2007-02-05 |  | 0d |  |  | 24h |
| 73 | 5.3.1 | Rascunhar Anotações para Demonstrativos Financeiros |  | 1d? | 2017-07-31 | 2017-08-01 | 71 | 0d |  | Diretor Financeiro/Controlador | 8h |
| 74 | 5.3.2 | Rascunhar 10-K |  | 1d? | 2017-08-01 | 2017-08-02 | 73 | 0d |  | Diretor Financeiro/Controlador | 8h |
| 75 | 5.3.3 | Rascunhar informações de Relatório aos Acionistas |  | 1d? | 2017-08-04 | 2017-08-07 | 74 | 0d |  | Departamento Jurídico | 8h |
| 76 | 5.3.4 | Rascunhos das Anotações do Demonstrativo Financeiro e do documento do SEC Concluídos | milestone | 0d | 2017-08-07 | 2017-08-07 | 75 | 0d |  |  |  |
| 77 | 5.4 | **Executar Auditoria Externa** |  | 4d? | 2007-02-14 | 2007-02-19 |  | 0d | 5d |  | 44h |
| 78 | 5.4.1 | Conduzir Auditorias Financeiras Externas e das Subsidiárias |  | 1d? | 2017-08-14 | 2017-08-14 | 91 | 0d |  | Auditores Externos | 8h |
| 79 | 5.4.2 | Conduzir Auditoria Financeira Corporativa |  | 1d? | 2017-08-14 | 2017-08-15 | 78 | 0d |  | Auditores Externos | 8h |
| 80 | 5.4.3 | Auditoria Externa Concluída | milestone | 0d | 2017-08-15 | 2017-08-15 | 79 | 0d |  |  |  |
| 81 | 5.4.4 | Analisar e Finalizar Resultados de Auditoria com o Comitê de Auditoria |  | 1d? | 2017-08-15 | 2017-08-16 | 80 | 0d |  | Comitê de Auditoria; Auditores Externos; Diretor Financeiro/Controlador | 12h |
| 82 | 5.4.5 | Aprovar Demonstrativos Financeiros/Obter Certificações de Gerenciamento Sênior |  | 1d? | 2017-08-18 | 2017-08-21 | 81 | 0d |  | Comitê de Auditoria; Diretor Financeiro/Controlador | 16h |
| 83 | 5.4.6 | Auditoria Externa Concluída | milestone | 0d | 2017-08-21 | 2017-08-21 | 82 | 0d |  |  |  |

Notes:
- 61: Definir a linha de base do cronograma de acordo com o tempo e os recursos necessários para alcançar a etapa de fechamento dos livros financeiros e gerar informações de demonstrativos financeiros necessárias para o Relatório Anual e o 10-K. / Em outras palavras, determinar primeiramente as datas e trabalhar de forma retroativa para determinar quando as atividades deverão ser iniciadas para atender a esses prazos finais.
- 77: As atividades de Auditoria Externa são realizadas no decorrer do ano. Essas atividades são centralizadas no fechamento do final do ano até a criação do relatório anual e os demonstrativos financeiros serem assinados pelos auditores externos.

| ID | WBS | Task | Type | Duration | Start | Finish | Predecessors | Total slack | Free slack | Resources | Work |
| --- | --- | --- | --- | --- | --- | --- | --- | --- | --- | --- | --- |
| 84 | 5.5 | **Executar Análise Jurídica Interna** |  | 6d? | 2007-02-06 | 2007-02-13 |  | 0d | 5d |  | 48h |
| 85 | 5.5.1 | Coordenar e analisar os eventos-chave significativos para inclusão no Relatório Anual |  | 1d? | 2017-08-07 | 2017-08-07 | 76 | 0d |  | Departamento Jurídico | 8h |
| 86 | 5.5.2 | Coordenar e analisar eventos-chave significativos para inclusão no 10-K |  | 1d? | 2017-08-07 | 2017-08-07 | 85 | 0d |  | Departamento Jurídico | 8h |
| 87 | 5.5.3 | Coordenar/desenvolver Relatório aos Acionistas |  | 1d? | 2017-08-07 | 2017-08-08 | 86 | 0d |  | Departamento Jurídico | 8h |
| 88 | 5.5.4 | Coordenar/analisar mensagem aos acionistas |  | 1d? | 2017-08-08 | 2017-08-09 | 87 | 0d |  | Departamento Jurídico | 8h |
| 89 | 5.5.5 | Coordenar/analisar revisão e comentários da Auditoria Externa |  | 1d? | 2017-08-11 | 2017-08-14 | 88 | 0d |  | Departamento Jurídico | 8h |
| 90 | 5.5.6 | Coordenar/analisar certificações de Gerenciamento Sênior |  | 1d? | 2017-08-14 | 2017-08-14 | 89 | 0d |  | Departamento Jurídico | 8h |
| 91 | 5.5.7 | Análise Jurídica Interna Concluída | milestone | 0d | 2017-08-14 | 2017-08-14 | 90 | 0d |  |  |  |
| 92 | 5.6 | Lançar publicamente os resultados financeiros |  | 0.5d? | 2017-08-21 | 2017-08-21 | 46, 83 | 0d |  | Comitê de Auditoria; Diretor Financeiro/Controlador; Depto. de RP/RI; Presidente | 8h |
| 93 | 5.7 | Fechamento Financeiro concluído |  | 1d? | 2017-08-21 | 2017-08-21 | 92 | 0d | 5d |  |  |
| 94 | 6 | **Produzir Relatório Anual** |  | 8d? | 2007-02-12 | 2007-02-22 |  | 0d |  |  | 64h |
| 95 | 6.1 | Rascunhar Layout do Design do Relatório Anual e Identificar Espaços Reservados |  | 1d? | 2017-08-11 | 2017-08-14 | 58 | 0d |  | Depto. de RP/RI | 8h |
| 96 | 6.2 | Preparar modelos de Gerenciamento Executivo |  | 1d? | 2017-08-14 | 2017-08-14 | 95 | 0d |  | Depto. de RP/RI | 8h |
| 97 | 6.3 | Repetir design/finalizar cronograma de produção |  | 1d? | 2017-08-14 | 2017-08-14 | 96 | 0d |  | Depto. de RP/RI | 8h |
| 98 | 6.4 | Finalizar dados de Design do Relatório Anual e de Espaço Reservado |  | 1d? | 2017-08-14 | 2017-08-15 | 97 | 0d |  | Depto. de RP/RI | 8h |
| 99 | 6.5 | Produzir Layout Final/Obter Aprovação Final |  | 1d? | 2017-08-15 | 2017-08-16 | 98 | 0d |  | Depto. de RP/RI | 8h |
| 100 | 6.6 | Imprimir Relatório Anual |  | 1d? | 2017-08-18 | 2017-08-21 | 99 | 0d |  | Depto. de RP/RI | 8h |
| 101 | 6.7 | Obter arquivo de documento do 10-K |  | 1d? | 2017-08-21 | 2017-08-21 | 100 | 0d |  | Depto. de RP/RI | 8h |
| 102 | 6.8 | Obter arquivo de documento do Relatório aos Acionistas |  | 1d? | 2017-08-21 | 2017-08-21 | 101 | 0d |  | Depto. de RP/RI | 8h |
| 103 | 6.9 | Produção do Relatório Anual Concluída | milestone | 0d | 2017-08-21 | 2017-08-21 | 102 | 0d |  |  |  |
| 104 | 7 | **Distribuir Relatório Anual** |  | 4d? | 2007-02-22 | 2007-02-28 |  | 0d |  |  | 32h |
| 105 | 7.1 | Obter listas finais para correspondência |  | 1d? | 2017-08-21 | 2017-08-22 | 103 | 0d |  | Depto. de RP/RI | 8h |
| 106 | 7.2 | Imprimir 10-Ks para correspondências do Relatório Anual |  | 1d? | 2017-08-22 | 2017-08-23 | 105 | 0d |  | Depto. de RP/RI | 8h |
| 107 | 7.3 | Imprimir Relatórios aos Acionistas para correspondências do Relatório Anual |  | 1d? | 2017-08-25 | 2017-08-28 | 106 | 0d |  | Depto. de RP/RI | 8h |
| 108 | 7.4 | Consolidar e enviar Relatórios Anuais |  | 1d? | 2017-08-28 | 2017-08-28 | 107 | 0d |  | Depto. de RP/RI | 8h |
| 109 | 7.5 | Distribuição Concluída | milestone | 0d | 2017-08-28 | 2017-08-28 | 108 | 0d |  |  |  |
| 110 | 8 | Relatório Anual Concluído | milestone | 0d | 2017-08-28 | 2017-08-28 | 109 | 0d |  |  |  |
